# 00375r0P802-15_TG1-Project-Planning-Effort

Schedule from MS Project, 1999-10-22 to 2001-09-13.
M/A-COM, Inc.

## Calendars

- Standard: Mon-Fri 08:00-12:00, 13:00-17:00; Sat-Sun off. Exceptions (off unless hours are given): 1999-10-01 to 2001-09-30 08:00-12:00, 13:00-17:00.

## Resources

| Resource |
| --- |
| Cypher |
| Siep |
| TG1 Editors |
| Gifford |

## Schedule

| ID | WBS | Task | Type | Duration | Start | Finish | Predecessors | Total slack | Free slack | Constraint |
| --- | --- | --- | --- | --- | --- | --- | --- | --- | --- | --- |
| 1 | 1 | **IEEE Std 802.15.1-[2001] Scenario A** |  | 692d | 1999-10-22 | 2001-09-13 |  | 0d |  |  |
| 2 | 1.1 | **WG Ballot Phase** |  | 498d | 1999-10-22 | 2001-03-02 |  | 194d |  |  |
| 3 | 1.1.1 | **Draft 0.6** |  | 134d | 1999-10-22 | 2000-03-03 |  | 558d |  |  |
| 4 | 1.1.1.1 | BSIG D0.6.0 Review |  | 14d | 1999-10-22 | 1999-11-04 |  | 660d |  | finish no earlier than 1999-11-04 |
| 5 | 1.1.1.2 | BSIG D0.6.0 Release | milestone | 0d | 1999-11-04 | 1999-11-04 |  | 550d | 0d | start no earlier than 1999-11-04 |
| 6 | 1.1.1.3 | Upload D0.6.0 to Web | milestone | 0d | 1999-11-04 | 1999-11-04 | 5 | 550d | 0d |  |
| 7 | 1.1.1.4 | Pre LB |  | 7d | 1999-11-04 | 1999-11-10 | 6 | 550d | 0d |  |
| 8 | 1.1.1.5 | LB1 D0.6.0 |  | 43d | 1999-11-11 | 1999-12-23 | 7 | 550d | 0d |  |
| 9 | 1.1.1.6 | LB1 Comment Resolution |  | 61d | 1999-12-24 | 2000-02-22 | 8 | 550d |  |  |
| 10 | 1.1.1.7 | LB2 Confirmation |  | 10d | 2000-02-23 | 2000-03-03 |  | 540d |  | start no earlier than 2000-02-23 |
| 11 | 1.1.2 | **Draft 0.7.2** |  | 283d | 2000-03-08 | 2000-12-15 |  | 271d |  |  |
| 12 | 1.1.2.1 | Editing D0.6 to D0.7.2 |  | 50d | 2000-03-08 | 2000-04-26 |  | 504d |  | start no earlier than 2000-03-08 |
| 13 | 1.1.2.2 | Upload D0.7.1 to Web | milestone | 0d | 2000-05-17 | 2000-05-17 |  | 271d | 0d | start no earlier than 2000-05-17 |
| 14 | 1.1.2.3 | Pre LB |  | 7d | 2000-05-17 | 2000-05-23 | 13 | 271d | 0d |  |
| 15 | 1.1.2.4 | LB3 D0.7.2 |  | 40d | 2000-05-24 | 2000-07-02 | 14 | 271d | 0d |  |
| 16 | 1.1.2.5 | LB3 Comment Resolution |  | 151d | 2000-07-03 | 2000-11-30 | 15 | 271d | 0d |  |
| 17 | 1.1.2.6 | LB6 Confirmation |  | 15d | 2000-12-01 | 2000-12-15 | 16 | 271d |  |  |
| 18 | 1.1.3 | Draft 0.7.3 | milestone | 0d | 2000-09-08 | 2000-09-08 |  | 99d | 0d | start no earlier than 2000-09-08 |
| 19 | 1.1.4 | **Draft 0.8** |  | 155d | 2000-09-08 | 2001-02-09 |  | 77d |  |  |
| 20 | 1.1.4.1 | Begin Editing |  | 90d | 2000-09-08 | 2000-12-06 | 18 | 99d | 22d |  |
| 21 | 1.1.4.2 | BSIG Releases BT v1.1 | milestone | 0d | 2000-12-29 | 2000-12-29 | 20 | 77d | 0d | start no earlier than 2000-12-29 |
| 22 | 1.1.4.3 | **Begin Final Editing D0.7.3 to D0.8** |  | 21d | 2000-12-29 | 2001-01-18 | 21 | 77d |  |  |
| 23 | 1.1.4.3.1 | SDL Final Editing BTv1.0B to v1.1 |  | 14d | 2000-12-29 | 2001-01-11 |  | 77d | 0d |  |
| 24 | 1.1.4.3.2 | Drop in BTv1.1 Derivative Text |  | 7d | 2000-12-29 | 2001-01-04 |  | 84d | 7d |  |
| 25 | 1.1.4.3.3 | Produce D0.7.4 Proof |  | 3d | 2001-01-12 | 2001-01-14 | 24, 23 | 77d | 0d |  |
| 26 | 1.1.4.3.4 | IEEE WG Distribution | milestone | 0d | 2001-01-14 | 2001-01-14 | 25 | 77d | 0d |  |
| 27 | 1.1.4.3.5 | TG1 D0.7.4 Proof Review |  | 4d | 2001-01-15 | 2001-01-18 | 26 | 77d | 0d |  |
| 28 | 1.1.4.3.6 | WG Approve D0.7.4 to D0.8 | milestone | 0d | 2001-01-18 | 2001-01-18 | 27 | 77d | 0d |  |
| 29 | 1.1.4.4 | Upload D0.8 to IEEE Web Site | milestone | 0d | 2001-01-18 | 2001-01-18 | 24, 28, 26 | 77d | 0d |  |
| 30 | 1.1.4.5 | LB(7) D0.8 |  | 15d | 2001-01-19 | 2001-02-02 | 29 | 77d | 0d |  |
| 31 | 1.1.4.6 | LB(7) Comment Resolution |  | 7d | 2001-02-03 | 2001-02-09 | 30 | 77d | 0d |  |
| 32 | 1.1.5 | Draft 0.9 (LB(9))? |  | 21d | 2001-02-10 | 2001-03-02 | 31 | 77d | 9d |  |

Notes:
- 18: Received a "smoothed" version from IEEE-SA Project Editor Jennifer Longman. This is the going forward draft for the IEEE Std 802.15.1-[2001] Draft 0.8.
- 32: IF we LB(7) fails and the WG or other party requires another recirculation then this task would be invoked. Ideally we go from LB(7) D0.8 to Sponsor Ballot after Comment Resolution.

| ID | WBS | Task | Type | Duration | Start | Finish | Predecessors | Total slack | Free slack | Constraint |
| --- | --- | --- | --- | --- | --- | --- | --- | --- | --- | --- |
| 33 | 1.2 | **Sponsor Ballot Phase** |  | 117d | 2001-03-12 | 2001-07-06 | 32 | 68d |  |  |
| 34 | 1.2.1 | Draft 1.0.0 |  | 68d | 2001-03-12 | 2001-05-18 |  | 68d | 0d | start no earlier than 2001-03-12 |
| 35 | 1.2.2 | Draft 1.0.1 |  | 28d | 2001-05-19 | 2001-06-15 | 34 | 68d | 0d |  |
| 36 | 1.2.3 | Draft 1.0.2 |  | 21d | 2001-06-16 | 2001-07-06 | 35 | 68d |  |  |
| 37 | 1.3 | **StD Board Approval D1.1** |  | 41d | 2001-08-03 | 2001-09-13 |  | 0d |  |  |
| 38 | 1.3.1 | RevCom Draft Deadline D1.1 | milestone | 0d | 2001-08-03 | 2001-08-03 |  | 41d |  | start no earlier than 2001-08-03 |
| 39 | 1.3.2 | Revcom Approval | milestone | 0d | 2001-09-13 | 2001-09-13 |  | 0d |  | start no earlier than 2001-09-13 |
